# "RECUPERACIÓN DEL LOCAL ESCOLAR PRIMARIA N° 14044 CON CÓDIGO LOCAL 413406 DISTRITO DE CATACAOS - PROVINCIA DE PIURA -DEPARTAMENTO DE PIURA"

Schedule from MS Project, 2020-04-01 to 2020-09-27.

## Calendars

- Estándar: Mon-Sun 08:00-13:00, 15:00-18:00.

## Schedule

| ID | WBS | Task | Duration | Start | Finish | Predecessors | Total slack | Cost |
| --- | --- | --- | --- | --- | --- | --- | --- | --- |
| 1 | 1 | **ESTRUCTURAS** | 175d | 2020-04-01 | 2020-09-22 |  | 0d | 1,935,303.18 |
| 2 | 1.1 | **OBRAS PROVISIONALES** | 175d | 2020-04-01 | 2020-09-22 |  | 0d | 32,021 |
| 3 | 1.1.1 | CARTEL DE IDENTIFICACION DE OBRA 3.60 X 7.20 M. (INC. TRANSPORTE E INSTALACION) | 2d | 2020-04-01 | 2020-04-02 |  | 0d | 1,216.78 |
| 4 | 1.1.2 | CASETA PARA ALMACENAMIENTO Y GUARDIANIA | 1d | 2020-04-01 | 2020-04-01 | 3SS | 174d | 2,680.61 |
| 5 | 1.1.3 | OFICINAS PARA RESIDENTE Y SUPERVISION GENERAL | 2d | 2020-04-01 | 2020-04-02 | 3SS | 173d | 4,786.8 |
| 6 | 1.1.4 | ALQUILER DE BAÑOS PORTATILES | 175d | 2020-04-01 | 2020-09-22 | 3SS | 0d | 10,800 |
| 7 | 1.1.5 | CERCO PROVISIONAL DE CAMPAMENTO (H=2.10m) CON MALLA RASCHELL | 2d | 2020-05-01 | 2020-05-02 | 475 | 143d | 3,633 |
| 8 | 1.1.6 | ENERGIA ELECTRICA PROVISIONAL | 2d | 2020-05-01 | 2020-05-02 | 475 | 143d | 2,003.81 |
| 9 | 1.1.7 | DEPOSITO PARA ALMACENAMIENTO DE AGUA | 2d | 2020-05-01 | 2020-05-02 | 475 | 143d | 250 |
| 10 | 1.1.8 | MOVILIZACION, INSTALAC, DESMOVILIZ, D/EQUIPO Y HERRAMIENTAS | 2d | 2020-05-01 | 2020-05-02 | 475 | 143d | 2,400 |
| 11 | 1.1.9 | FLETE TERRESTRE | 2d | 2020-05-01 | 2020-05-02 | 475 | 143d | 4,250 |
| 12 | 1.2 | **SEGURIDAD Y SALUD** | 175d | 2020-04-01 | 2020-09-22 |  | 0d | 41,185.61 |
| 13 | 1.2.1 | ELABORACION ,IMPLEMENTACION Y ADMINISTRACION DEL PLAN DE SEGURIDAD Y SALUD EN EL TRABAJO | 175d | 2020-04-01 | 2020-09-22 | 3SS | 0d | 8,000 |
| 14 | 1.2.2 | EQUIPOS DE PROTECCION INDIVIDUAL | 175d | 2020-04-01 | 2020-09-22 | 3SS | 0d | 10,385.61 |
| 15 | 1.2.3 | EQUIPOS DE PROTECCION COLECTIVA | 175d | 2020-04-01 | 2020-09-22 | 3SS | 0d | 2,500 |
| 16 | 1.2.4 | SEÑALIZACION TEMPORAL DE SEGURIDAD | 175d | 2020-04-01 | 2020-09-22 | 3SS | 0d | 2,200 |
| 17 | 1.2.5 | CAPACITACION EN SEGURIDAD Y SALUD | 175d | 2020-04-01 | 2020-09-22 | 3SS | 0d | 10,200 |
| 18 | 1.2.6 | RECURSOS PARA RESPUESTAS ANTE EMERGENCIAS EN SEGURIDAD Y SALUD DURANTE EL TRABAJO | 175d | 2020-04-01 | 2020-09-22 | 3SS | 0d | 3,900 |
| 19 | 1.2.7 | MITIGACION DE IMPACTO AMBIENTAL | 175d | 2020-04-01 | 2020-09-22 | 3SS | 0d | 4,000 |
| 20 | 1.3 | **PARTIDAS COVID 19** | 175d | 2020-04-01 | 2020-09-22 |  | 0d | 44,086.63 |
| 21 | 1.3.1 | ELABORACION DEL PLAN DE VIGILANCIA, PREVENCION Y CONTROL DE COVID 19 | 15d | 2020-04-01 | 2020-04-15 | 3SS | 160d | 5,500 |
| 22 | 1.3.2 | LIMPIEZA Y DESINFECCION DE CENTROS DE TRABAJO | 175d | 2020-04-01 | 2020-09-22 | 3SS | 0d | 13,288.2 |
| 23 | 1.3.3 | EVALUACION DE LA CONDICION DE SALUD DEL TRABAJADOR PREVIO AL REGRESO E INCORPORACION AL CENTRO DE TRABAJO | 175d | 2020-04-01 | 2020-09-22 | 3SS | 0d | 6,000 |
| 24 | 1.3.4 | LAVADO Y DESINFECCION DE MANOS OBLIGATORIO | 175d | 2020-04-01 | 2020-09-22 | 3SS | 0d | 1,726.2 |
| 25 | 1.3.5 | SENSIBILIZACION DE LA PREVENCION DEL CONTAGIO EN EL CENTRO DE TRABAJO | 175d | 2020-04-01 | 2020-09-22 | 3SS | 0d | 750 |
| 26 | 1.3.6 | MEDIDAS PREVENTIVAS DE APLICACION COLECTIVA | 175d | 2020-04-01 | 2020-09-22 | 3SS | 0d | 1,152.3 |
| 27 | 1.3.7 | MEDIDAS DE PROTECCION PERSONAL (40 PERSONAS) | 175d | 2020-04-01 | 2020-09-22 | 3SS | 0d | 9,144 |
| 28 | 1.3.8 | VIGILANCIA DE LA SALUD EN EL TRABAJO EN EL CONTEXTO DE COVID 19. | 175d | 2020-04-01 | 2020-09-22 | 3SS | 0d | 6,525.93 |

| ID | WBS | Task | Duration | Start | Finish | Predecessors | Total slack | Free slack | Cost |
| --- | --- | --- | --- | --- | --- | --- | --- | --- | --- |
| 29 | 1.4 | **DESMONTAJES Y DEMOLICIONES** | 4d | 2020-05-01 | 2020-05-04 |  | 0d |  | 74,594.05 |
| 30 | 1.4.1 | DESMONTAJE DE PUERTAS | 3d | 2020-05-01 | 2020-05-03 | 475 | 0d |  | 775.5 |
| 31 | 1.4.2 | DESMONTAJE DE VENTANAS | 1d | 2020-05-01 | 2020-05-01 | 30SS | 144d |  | 1,142.26 |
| 32 | 1.4.3 | DESMONTAJE DE TECHO DE ETERNIT/CALAMINA | 2d | 2020-05-01 | 2020-05-02 | 30SS | 143d |  | 7,328.77 |
| 33 | 1.4.4 | DEMOLICION DE CIMIENTOS | 4d | 2020-05-01 | 2020-05-04 | 30SS | 0d |  | 19,163.64 |
| 34 | 1.4.5 | DEMOLICION DE SOBRECIMIENTOS | 3d | 2020-05-01 | 2020-05-03 | 30SS | 142d |  | 2,395.46 |
| 35 | 1.4.6 | DEMOLICION DE COLUMNAS | 4d | 2020-05-01 | 2020-05-04 | 30SS | 0d |  | 3,183.67 |
| 36 | 1.4.7 | DEMOLICION DE PISOS Y VEREDAS E=0.10 M. | 4d | 2020-05-01 | 2020-05-04 | 30SS | 0d |  | 20,260.41 |
| 37 | 1.4.8 | DEMOLICION DE MUROS E=0.25 M. INCLUYE VIGAS DE CONFINAMIENTO. | 3d | 2020-05-01 | 2020-05-03 | 30SS | 142d |  | 20,344.34 |
| 38 | 1.5 | **MOVIMIENTO DE TIERRAS** | 2d | 2020-05-05 | 2020-05-06 |  | 0d |  | 83,342.3 |
| 39 | 1.5.1 | CORTE DE TERRENO A NIVEL DE SUBRASANTE C/MAQUINARIA | 2d | 2020-05-05 | 2020-05-06 | 36, 35, 33 | 0d |  | 3,323.26 |
| 40 | 1.5.2 | RELLENO COMPACTADO MAT/PRESTAMO | 1d | 2020-05-06 | 2020-05-06 | 39FF | 0d |  | 50,385.38 |
| 41 | 1.5.3 | ELIMINACION DE MATERIAL EXCEDENTE DP=5KM | 1d | 2020-05-06 | 2020-05-06 | 40FF | 0d |  | 29,633.66 |
| 42 | 1.6 | **CERCO PERIMETRICO** | 56d | 2020-05-08 | 2020-07-02 |  | 82d |  | 149,478.18 |
| 43 | 1.6.1 | **OBRAS PRELIMINARES** | 1d | 2020-05-08 | 2020-05-08 |  | 137d |  | 87.45 |
| 44 | 1.6.1.1 | TRAZO DE NIVELES Y REPLANTEO | 1d | 2020-05-08 | 2020-05-08 | 103FF | 137d |  | 87.45 |
| 45 | 1.6.2 | **MOVIMIENTO DE TIERRAS** | 45d | 2020-05-11 | 2020-06-24 |  | 90d |  | 17,985.86 |
| 46 | 1.6.2.1 | EXCAVACION MANUAL PARA ZANJAS | 3d | 2020-05-11 | 2020-05-13 | 105FF | 131d | 0d | 7,131.08 |
| 47 | 1.6.2.2 | NIVELACION Y COMPACTACION DE AREA DE FONDO DE CIMENTACION | 1d | 2020-05-15 | 2020-05-15 | 109FF | 130d |  | 469.32 |
| 48 | 1.6.2.3 | RELLENO COMPACTADO MAT/PROPIO | 3d | 2020-06-22 | 2020-06-24 | 134 | 90d |  | 418.71 |
| 49 | 1.6.2.4 | RELLENO COMPACTADO C/EQUIPO MAT. AFIRMADO EN FONDO DE CIMENTACION | 1d | 2020-06-22 | 2020-06-22 | 134 | 92d |  | 2,647.46 |
| 50 | 1.6.2.5 | ACARREO INTERNO, MATERIAL PROCEDENTE DE EXCAVACIONES | 1d | 2020-05-14 | 2020-05-14 | 46 | 131d |  | 3,126.39 |
| 51 | 1.6.2.6 | ELIMINACION DE MATERIAL EXCEDENTE DP=5KM | 1d | 2020-05-13 | 2020-05-13 | 105FF | 132d |  | 4,192.9 |
| 52 | 1.6.3 | **CONCRETO SIMPLE** | 12d | 2020-05-16 | 2020-05-27 |  | 89d |  | 37,922.41 |
| 53 | 1.6.3.1 | SOLADO DE CONCRETO C:H 1/12 E=5CM | 1d | 2020-05-16 | 2020-05-16 | 116FF | 129d |  | 4,882.63 |
| 54 | 1.6.3.2 | CIMIENTOS CORRIDOS C:H 1/10 + 30% PIEDRA GRANDE | 2d | 2020-05-26 | 2020-05-27 | 123 | 79d | 0d | 33,039.78 |

| ID | WBS | Task | Duration | Start | Finish | Predecessors | Total slack | Free slack | Cost |
| --- | --- | --- | --- | --- | --- | --- | --- | --- | --- |
| 55 | 1.6.4 | **CONCRETO ARMADO** | 35d | 2020-05-29 | 2020-07-02 |  | 79d |  | 93,482.46 |
| 56 | 1.6.4.1 | **SOBRECIMIENTOS REFORZADOS** | 20d | 2020-05-29 | 2020-06-17 |  | 79d |  | 28,892.76 |
| 57 | 1.6.4.1.1 | SOBREC. REF. ACERO F'Y=4200 kg/cm2 | 7d | 2020-05-29 | 2020-06-04 | 54FS+1d | 79d | 0d | 9,745.79 |
| 58 | 1.6.4.1.2 | SOBREC. REF. ENCOFRADO Y DESENCOFRADO | 5d | 2020-06-05 | 2020-06-09 | 57 | 79d | 0d | 11,374.25 |
| 59 | 1.6.4.1.3 | SOBREC. REF. CONCRETO F'C=210 KG/CM2 | 1d | 2020-06-10 | 2020-06-10 | 58 | 79d | 0d | 7,468.13 |
| 60 | 1.6.4.1.4 | CURADO QUIMICO DE CONCRETO | 7d | 2020-06-11 | 2020-06-17 | 59 | 97d |  | 304.59 |
| 61 | 1.6.4.2 | **COLUMNAS** | 15d | 2020-06-18 | 2020-07-02 |  | 79d |  | 49,478.76 |
| 62 | 1.6.4.2.1 | COLUMNAS, ACERO F'Y=4200 kg/cm2 | 3d | 2020-06-18 | 2020-06-20 | 288 | 79d | 0d | 20,677.25 |
| 63 | 1.6.4.2.2 | COLUMNAS, ENCOFRADO Y DESENCOFRADO | 4d | 2020-06-21 | 2020-06-24 | 62 | 79d | 0d | 20,101.8 |
| 64 | 1.6.4.2.3 | COLUMNAS, CONCRETO F'C=210 kg/cm2 | 1d | 2020-06-25 | 2020-06-25 | 63 | 80d | 0d | 8,161.4 |
| 65 | 1.6.4.2.4 | CURADO QUIMICO DE CONCRETO | 7d | 2020-06-26 | 2020-07-02 | 64 | 82d |  | 538.31 |
| 66 | 1.6.4.3 | **VIGAS** | 11d | 2020-06-18 | 2020-06-28 |  | 79d | 0d | 15,110.94 |
| 67 | 1.6.4.3.1 | VIGAS, ACERO F'Y=4200 kg/cm2 | 2d | 2020-06-18 | 2020-06-19 | 288 | 88d |  | 4,223.49 |
| 68 | 1.6.4.3.2 | VIGAS, ENCOFRADO Y DESENCOFRADO | 4d | 2020-06-25 | 2020-06-28 | 63 | 79d |  | 6,597.53 |
| 69 | 1.6.4.3.3 | VIGAS, CONCRETO f'c=210 kg/cm2 | 1d | 2020-06-26 | 2020-06-26 | 64 | 80d | 0d | 4,046.98 |
| 70 | 1.6.4.3.4 | CURADO QUIMICO DE CONCRETO | 1d | 2020-06-27 | 2020-06-27 | 69 | 80d |  | 242.94 |
| 71 | 1.7 | **PORTADA DE INGRESO** | 9d | 2020-08-03 | 2020-08-11 |  | 41d |  | 20,393.45 |
| 72 | 1.7.1 | **MOVIMIENTO DE TIERRAS** | 5d | 2020-08-03 | 2020-08-07 |  | 41d |  | 982.35 |
| 73 | 1.7.1.1 | EXCAVACION MANUAL PARA ZANJAS | 1d | 2020-08-03 | 2020-08-03 | 222 | 41d | 0d | 433.88 |
| 74 | 1.7.1.2 | NIVELACION Y COMPACTACION DE AREA DE FONDO DE CIMENTACION | 1d | 2020-08-03 | 2020-08-03 | 73SS | 41d | 0d | 28.85 |
| 75 | 1.7.1.3 | RELLENO COMPACTADO C/EQUIPO MAT. AFIRMADO EN FONDO DE CIMENTACION | 1d | 2020-08-03 | 2020-08-03 | 74SS | 41d | 0d | 122.32 |
| 76 | 1.7.1.4 | RELLENO COMPACTADO MAT/PROPIO | 1d | 2020-08-05 | 2020-08-05 | 82SS | 46d | 0d | 59.68 |
| 77 | 1.7.1.5 | ACARREO INTERNO, MATERIAL PROCEDENTE DE EXCAVACIONES | 1d | 2020-08-06 | 2020-08-06 | 76 | 46d | 0d | 131.35 |
| 78 | 1.7.1.6 | ELIMINACION DE MATERIAL EXCEDENTE DP=5KM | 1d | 2020-08-07 | 2020-08-07 | 77 | 46d |  | 206.27 |

| ID | WBS | Task | Duration | Start | Finish | Predecessors | Total slack | Free slack | Cost |
| --- | --- | --- | --- | --- | --- | --- | --- | --- | --- |
| 79 | 1.7.2 | **CONCRETO SIMPLE** | 1d | 2020-08-04 | 2020-08-04 |  | 41d |  | 502.48 |
| 80 | 1.7.2.1 | SOLADO DE CONCRETO C:H 1/12 E=10 CM | 1d | 2020-08-04 | 2020-08-04 | 75 | 41d | 0d | 502.48 |
| 81 | 1.7.3 | **CONCRETO ARMADO** | 7d | 2020-08-05 | 2020-08-11 |  | 41d |  | 18,908.62 |
| 82 | 1.7.3.1 | **ZAPATAS** | 4d | 2020-08-05 | 2020-08-08 |  | 41d | 0d | 3,100.77 |
| 83 | 1.7.3.1.1 | ZAPATAS, ACERO F'Y=4200 kg/cm2 | 1d | 2020-08-05 | 2020-08-05 | 80 | 48d |  | 315.81 |
| 84 | 1.7.3.1.2 | ZAPATAS, CONCRETO f'c=210 kg/cm² | 1d | 2020-08-05 | 2020-08-05 | 80 | 41d | 0d | 2,772.63 |
| 85 | 1.7.3.1.3 | CURADO QUIMICO DE CONCRETO | 3d | 2020-08-06 | 2020-08-08 | 84 | 45d |  | 12.33 |
| 86 | 1.7.3.2 | **COLUMNAS** | 3d | 2020-08-05 | 2020-08-07 |  | 42d | 0d | 6,341.32 |
| 87 | 1.7.3.2.1 | COLUMNAS, ACERO F'Y=4200 kg/cm2 | 1d | 2020-08-05 | 2020-08-05 | 80 | 45d |  | 1,774.14 |
| 88 | 1.7.3.2.2 | COLUMNAS, ENCOFRADO Y DESENCOFRADO | 1d | 2020-08-06 | 2020-08-06 | 84 | 44d |  | 3,063.09 |
| 89 | 1.7.3.2.3 | COLUMNAS, CONCRETO F'C=210 kg/cm2 | 1d | 2020-08-06 | 2020-08-06 | 84 | 41d | 0d | 1,422.06 |
| 90 | 1.7.3.2.4 | CURADO QUIMICO DE CONCRETO | 1d | 2020-08-07 | 2020-08-07 | 89 | 43d |  | 82.03 |
| 91 | 1.7.3.3 | **VIGAS** | 4d | 2020-08-07 | 2020-08-10 |  | 41d | 0d | 7,947.57 |
| 92 | 1.7.3.3.1 | VIGAS, ACERO F'Y=4200 kg/cm2 | 1d | 2020-08-07 | 2020-08-07 | 89 | 41d | 0d | 323.31 |
| 93 | 1.7.3.3.2 | VIGAS, ENCOFRADO Y DESENCOFRADO | 1d | 2020-08-08 | 2020-08-08 | 92 | 43d |  | 582.66 |
| 94 | 1.7.3.3.3 | VIGAS, CONCRETO f'c=210 kg/cm2 | 1d | 2020-08-08 | 2020-08-08 | 92 | 41d | 0d | 7,026 |
| 95 | 1.7.3.3.4 | CURADO QUIMICO DE CONCRETO | 2d | 2020-08-09 | 2020-08-10 | 94 | 41d |  | 15.6 |
| 96 | 1.7.3.4 | **PLACAS** | 5d | 2020-08-07 | 2020-08-11 |  | 42d |  | 1,518.96 |
| 97 | 1.7.3.4.1 | PLACAS, ACERO F'Y=4200 kg/cm2 | 1d | 2020-08-07 | 2020-08-07 | 89 | 46d |  | 256.65 |
| 98 | 1.7.3.4.2 | PLACAS, ENCOFRADO Y DESENCOFRADO | 1d | 2020-08-08 | 2020-08-08 | 92 | 45d |  | 769.55 |
| 99 | 1.7.3.4.3 | PLACAS, CONCRETO f'c=210 kg/cm2 | 1d | 2020-08-08 | 2020-08-08 | 92 | 45d |  | 472.15 |
| 100 | 1.7.3.4.4 | CURADO QUIMICO DE CONCRETO | 3d | 2020-08-09 | 2020-08-11 | 94 | 42d |  | 20.61 |
| 101 | 1.8 | **MODULOS** | 126d | 2020-05-07 | 2020-09-09 |  | 0d |  | 1,110,412.47 |
| 102 | 1.8.1 | **OBRAS PRELIMINARES** | 2d | 2020-05-07 | 2020-05-08 |  | 0d |  | 414.43 |
| 103 | 1.8.1.1 | TRAZO DE NIVELES Y REPLANTEO | 2d | 2020-05-07 | 2020-05-08 | 38 | 0d |  | 414.43 |

| ID | WBS | Task | Duration | Start | Finish | Predecessors | Total slack | Free slack | Cost |
| --- | --- | --- | --- | --- | --- | --- | --- | --- | --- |
| 104 | 1.8.2 | **MOVIMIENTO DE TIERRAS** | 62d | 2020-05-09 | 2020-07-09 |  | 0d |  | 91,517.72 |
| 105 | 1.8.2.1 | EXCAVACION MASIVA C/MAQUINARIA PARA CIMENTACION | 5d | 2020-05-09 | 2020-05-13 | 103 | 0d |  | 3,210.39 |
| 106 | 1.8.2.2 | SUMINISTRO DE OVER SEGUN ESPECIFICACIONES TECNICAS | 2d | 2020-05-09 | 2020-05-10 | 103 | 135d |  | 15,413.42 |
| 107 | 1.8.2.3 | SUMINISTRO DE HORMIGON | 2d | 2020-05-09 | 2020-05-10 | 103 | 135d |  | 6,966.33 |
| 108 | 1.8.2.4 | COLOCACION DE OVER PARA CIMENTACION | 5d | 2020-05-09 | 2020-05-13 | 105FF | 0d |  | 9,587.31 |
| 109 | 1.8.2.5 | COLOCACION DE HORMIGON COMPACTADO | 2d | 2020-05-14 | 2020-05-15 | 108 | 0d |  | 3,834.81 |
| 110 | 1.8.2.6 | RELLENO COMPACTADO MAT/PROPIO | 2d | 2020-06-22 | 2020-06-23 | 134 | 75d | 0d | 5,495.03 |
| 111 | 1.8.2.7 | NIVELACION INTERIOR Y APISONADO PARA FALSO PISO Y VEREDA | 3d | 2020-06-24 | 2020-06-26 | 110 | 76d | 0d | 1,919.08 |
| 112 | 1.8.2.8 | AFIRMADO PARA FALSO PISO, COMPACTADO | 9d | 2020-06-27 | 2020-07-05 | 111 | 76d | 0d | 9,405.96 |
| 113 | 1.8.2.9 | ACARREO INTERNO, MATERIAL PROCEDENTE DE EXCAVACIONES | 16d | 2020-06-24 | 2020-07-09 | 110 | 75d |  | 12,238.17 |
| 114 | 1.8.2.10 | ELIMINACION DE MATERIAL EXCEDENTE DP=5KM | 3d | 2020-06-24 | 2020-06-26 | 110 | 88d |  | 23,447.22 |
| 115 | 1.8.3 | **CONCRETO SIMPLE** | 53d | 2020-05-16 | 2020-07-07 |  | 0d |  | 60,804.61 |
| 116 | 1.8.3.1 | SOLADO DE CONCRETO C:H 1/12 E=10 CM | 1d | 2020-05-16 | 2020-05-16 | 109 | 0d |  | 32,856.15 |
| 117 | 1.8.3.2 | CIMIENTOS CORRIDOS C:H 1/10 + 30% PIEDRA GRANDE | 5d | 2020-05-17 | 2020-05-21 | 116 | 124d |  | 8,682.15 |
| 118 | 1.8.3.3 | FALSO PISO, F'C=175 KG/CM2 | 2d | 2020-07-06 | 2020-07-07 | 112 | 76d | 0d | 19,266.31 |
| 119 | 1.8.4 | **CONCRETO ARMADO** | 116d | 2020-05-17 | 2020-09-09 |  | 0d |  | 957,675.71 |
| 120 | 1.8.4.1 | **PLATEA DE CIMENTACION** | 11d | 2020-05-17 | 2020-05-27 |  | 0d |  | 244,563.69 |
| 121 | 1.8.4.1.1 | PLATEA DE CIMENTACION, ACERO F'Y=4200 kg/cm2 | 3d | 2020-05-17 | 2020-05-19 | 116 | 0d |  | 109,278.41 |
| 122 | 1.8.4.1.2 | PLATEA DE CIMENTACION, ENCOFRADO Y DESENCOFRADO | 3d | 2020-05-20 | 2020-05-22 | 121 | 0d |  | 4,615.25 |
| 123 | 1.8.4.1.3 | PLATEA DE CIMENTACION, CONCRETO f'c=210 kg/cm² | 3d | 2020-05-23 | 2020-05-25 | 122 | 65d | 0d | 129,471.93 |
| 124 | 1.8.4.1.4 | CURADO QUIMICO DE CONCRETO | 2d | 2020-05-26 | 2020-05-27 | 123 | 65d | 0d | 1,198.1 |
| 125 | 1.8.4.2 | **PEDESTALES** | 9d | 2020-05-28 | 2020-06-05 |  | 109d |  | 11,412.64 |
| 126 | 1.8.4.2.1 | PEDESTALES, ENCOFRADO Y DESENCOFRADO | 1d | 2020-05-28 | 2020-05-28 | 124 | 109d | 0d | 3,760.5 |
| 127 | 1.8.4.2.2 | PEDESTALES, CONCRETO f'c=210 kg/cm² | 1d | 2020-05-29 | 2020-05-29 | 126 | 109d | 0d | 7,551.44 |
| 128 | 1.8.4.2.3 | CURADO QUIMICO DE CONCRETO | 7d | 2020-05-30 | 2020-06-05 | 127 | 109d |  | 100.7 |

| ID | WBS | Task | Duration | Start | Finish | Predecessors | Total slack | Free slack | Cost |
| --- | --- | --- | --- | --- | --- | --- | --- | --- | --- |
| 129 | 1.8.4.3 | **VIGAS DE CIMENTACION** | 22d | 2020-05-24 | 2020-06-14 |  | 0d |  | 57,832.07 |
| 130 | 1.8.4.3.1 | VIGA DE CIMENTACION, ACERO F'Y=4200 kg/cm2 | 5d | 2020-05-24 | 2020-05-28 | 140 | 0d |  | 25,342.87 |
| 131 | 1.8.4.3.2 | VIGAS DE CIMENTACION ENCOFRADO Y DESENCOFRADO | 5d | 2020-05-29 | 2020-06-02 | 130 | 0d |  | 18,946.1 |
| 132 | 1.8.4.3.3 | VIGAS DE CIMENTACION, CONCRETO f'c=210 kg/cm² | 5d | 2020-06-03 | 2020-06-07 | 131 | 0d |  | 13,061.79 |
| 133 | 1.8.4.3.4 | CURADO QUIMICO DE CONCRETO | 7d | 2020-06-08 | 2020-06-14 | 132 | 0d |  | 481.31 |
| 134 | 1.8.4.4 | **SOBRECIMIENTOS REFORZADOS** | 14d | 2020-06-08 | 2020-06-21 |  | 54d | 0d | 12,612.94 |
| 135 | 1.8.4.4.1 | SOBREC. REF. ACERO F'Y=4200 kg/cm2 | 3d | 2020-06-08 | 2020-06-10 | 132 | 54d | 0d | 4,822.35 |
| 136 | 1.8.4.4.2 | SOBREC. REF. ENCOFRADO Y DESENCOFRADO | 3d | 2020-06-11 | 2020-06-13 | 135 | 75d | 0d | 4,788.4 |
| 137 | 1.8.4.4.3 | SOBREC. REF. CONCRETO F'C=210 KG/CM2 | 1d | 2020-06-14 | 2020-06-14 | 136 | 75d | 0d | 2,880.14 |
| 138 | 1.8.4.4.4 | CURADO QUIMICO DE CONCRETO | 7d | 2020-06-15 | 2020-06-21 | 137 | 75d |  | 122.05 |
| 139 | 1.8.4.5 | **COLUMNAS** | 80d | 2020-05-20 | 2020-08-07 |  | 0d |  | 201,972.34 |
| 140 | 1.8.4.5.1 | COLUMNAS, ACERO F'Y=4200 kg/cm2 | 4d | 2020-05-20 | 2020-05-23 | 122SS | 0d |  | 90,483.72 |
| 141 | 1.8.4.5.2 | COLUMNAS, ENCOFRADO Y DESENCOFRADO | 50d | 2020-06-08 | 2020-07-27 | 132 | 0d |  | 61,437.05 |
| 142 | 1.8.4.5.3 | COLUMNAS, CONCRETO F'C=210 kg/cm2 | 51d | 2020-06-13 | 2020-08-02 | 141FS-45d | 0d |  | 48,406.33 |
| 143 | 1.8.4.5.4 | CURADO QUIMICO DE CONCRETO | 50d | 2020-06-19 | 2020-08-07 | 142FS-45d | 0d |  | 1,645.24 |
| 144 | 1.8.4.6 | **VIGAS** | 50d | 2020-06-24 | 2020-08-12 |  | 0d |  | 165,485.9 |
| 145 | 1.8.4.6.1 | VIGAS, ACERO F'Y=4200 kg/cm2 | 35d | 2020-07-09 | 2020-08-12 | 143FS-30d | 0d |  | 77,194.82 |
| 146 | 1.8.4.6.2 | VIGAS, ENCOFRADO Y DESENCOFRADO | 35d | 2020-07-04 | 2020-08-07 | 145FS-40d | 0d |  | 40,180.23 |
| 147 | 1.8.4.6.3 | VIGAS, CONCRETO f'c=210 kg/cm2 | 35d | 2020-06-29 | 2020-08-02 | 146FS-40d | 0d |  | 47,034.85 |
| 148 | 1.8.4.6.4 | CURADO QUIMICO DE CONCRETO | 35d | 2020-06-24 | 2020-07-28 | 147FS-40d | 0d |  | 1,076 |
| 149 | 1.8.4.7 | **COLUMNAS DE CONFINAMIENTO EN TABIQUES** | 50d | 2020-06-11 | 2020-07-30 |  | 54d |  | 36,396.93 |
| 150 | 1.8.4.7.1 | COLUMNAS, ACERO F'Y=4200 kg/cm2 | 35d | 2020-06-11 | 2020-07-15 | 135 | 54d | 0d | 12,281.54 |
| 151 | 1.8.4.7.2 | COLUMNAS, ENCOFRADO Y DESENCOFRADO | 35d | 2020-06-16 | 2020-07-20 | 150FS-30d | 54d | 0d | 15,992.25 |
| 152 | 1.8.4.7.3 | COLUMNAS, CONCRETO F'C=210 kg/cm2 | 35d | 2020-06-21 | 2020-07-25 | 151FS-30d | 54d | 0d | 7,694.88 |
| 153 | 1.8.4.7.4 | CURADO QUIMICO DE CONCRETO | 35d | 2020-06-26 | 2020-07-30 | 152FS-30d | 54d |  | 428.26 |

| ID | WBS | Task | Duration | Start | Finish | Predecessors | Total slack | Free slack | Cost |
| --- | --- | --- | --- | --- | --- | --- | --- | --- | --- |
| 154 | 1.8.4.8 | **VIGAS DE CONFINAMIENTO** | 40d | 2020-08-01 | 2020-09-09 |  | 13d |  | 12,533.5 |
| 155 | 1.8.4.8.1 | VIGAS DE CONFINAMIENTO , ACERO FY=4.200KG/CM2 | 25d | 2020-08-01 | 2020-08-25 | 311 | 13d | 0d | 4,601.12 |
| 156 | 1.8.4.8.2 | VIGAS DE CONFINAMIENTO , ENCOFRADO Y DESENCOFRADO | 25d | 2020-08-06 | 2020-08-30 | 155FS-20d | 13d | 0d | 4,835.12 |
| 157 | 1.8.4.8.3 | VIGAS DE CONFINAMIENTO , CONCRETO F'C =175KG/CM2 | 25d | 2020-08-11 | 2020-09-04 | 156FS-20d | 13d | 0d | 2,967.78 |
| 158 | 1.8.4.8.4 | CURADO QUIMICO DE CONCRETO | 25d | 2020-08-16 | 2020-09-09 | 157FS-20d | 13d |  | 129.48 |
| 159 | 1.8.4.9 | **LOSAS ALIGERADAS** | 65d | 2020-06-19 | 2020-08-22 |  | 0d |  | 197,767.69 |
| 160 | 1.8.4.9.1 | LOSAS ALIGERADAS, ENCOFRADO Y DESENCOFRADO | 45d | 2020-06-19 | 2020-08-02 | 148FS-40d | 0d |  | 71,378.01 |
| 161 | 1.8.4.9.2 | LADRILLO HUECO DE ARCILLA 15X30X30CM PARA TECHO ALIGERADO | 45d | 2020-06-24 | 2020-08-07 | 160FS-40d | 0d |  | 31,341.96 |
| 162 | 1.8.4.9.3 | LOSAS ALIGERADAS, ACERO FY=4.200KG/CM2 | 45d | 2020-06-29 | 2020-08-12 | 161FS-40d | 0d |  | 45,757.13 |
| 163 | 1.8.4.9.4 | LOSAS ALIGERADAS, CONCRETO f'c=210 kg/cm2, E=0.20m | 45d | 2020-07-04 | 2020-08-17 | 162FS-40d | 0d |  | 47,379.14 |
| 164 | 1.8.4.9.5 | CURADO QUIMICO DE CONCRETO | 45d | 2020-07-09 | 2020-08-22 | 163FS-40d | 0d |  | 1,911.45 |
| 165 | 1.8.4.10 | **ESCALERAS** | 14d | 2020-08-03 | 2020-08-16 |  | 37d |  | 17,098.01 |
| 166 | 1.8.4.10.1 | ESCALERAS, ENCOFRADO Y DESENCOFRADO | 11d | 2020-08-03 | 2020-08-13 | 145FS-10d | 37d | 0d | 3,175.78 |
| 167 | 1.8.4.10.2 | ESCALERAS, ACERO F'Y=4200 kg/cm2 | 11d | 2020-08-04 | 2020-08-14 | 166FS-10d | 37d | 0d | 9,465.34 |
| 168 | 1.8.4.10.3 | ESCALERAS CONCRETO f'c=210 kg/cm2 | 11d | 2020-08-05 | 2020-08-15 | 167FS-10d | 37d | 0d | 4,316.2 |
| 169 | 1.8.4.10.4 | CURADO QUIMICO DE CONCRETO | 11d | 2020-08-06 | 2020-08-16 | 168FS-10d | 37d |  | 140.69 |
| 170 | 1.9 | **CISTERNA SUBTERRANEA** | 6d | 2020-05-28 | 2020-06-02 |  | 65d |  | 10,388.91 |
| 171 | 1.9.1 | **MOVIMIENTO DE TIERRAS** | 1d | 2020-05-28 | 2020-05-28 |  | 65d |  | 662.91 |
| 172 | 1.9.1.1 | EXCAVACION MANUAL PARA ZANJAS, H>1.50M | 1d | 2020-05-28 | 2020-05-28 | 120 | 65d | 0d | 662.91 |
| 173 | 1.9.2 | **CONCRETO SIMPLE** | 1d | 2020-05-29 | 2020-05-29 |  | 106d |  | 432.38 |
| 174 | 1.9.2.1 | SOLADO DE CONCRETO C:H 1/12 E=10 CM | 1d | 2020-05-29 | 2020-05-29 | 172 | 106d | 0d | 432.38 |
| 175 | 1.9.3 | **CONCRETO ARMADO** | 4d | 2020-05-30 | 2020-06-02 |  | 106d | 0d | 9,293.62 |
| 176 | 1.9.3.1 | ACERO fy=4200 kg/cm2 GRADO 60, PARA CISTERNA SUBTERRANEA | 2d | 2020-06-01 | 2020-06-02 | 177 | 106d |  | 3,678.33 |
| 177 | 1.9.3.2 | ENCOFRADO PARA CISTERNA SUBTERRANEA | 2d | 2020-05-30 | 2020-05-31 | 174 | 106d | 0d | 2,490.05 |
| 178 | 1.9.3.3 | CONCRETO F'C=210 KG/CM2 PARA CISTERNA SUBTERRANEA | 1d | 2020-06-01 | 2020-06-01 | 177 | 106d | 0d | 3,037.4 |
| 179 | 1.9.3.4 | CURADO QUIMICO DE CONCRETO | 1d | 2020-06-02 | 2020-06-02 | 178 | 106d |  | 87.84 |

| ID | WBS | Task | Duration | Start | Finish | Predecessors | Total slack | Free slack | Cost |
| --- | --- | --- | --- | --- | --- | --- | --- | --- | --- |
| 180 | 1.10 | **TANQUE ELEVADO** | 53d | 2020-05-28 | 2020-07-19 |  | 65d | 0d | 22,033.87 |
| 181 | 1.10.1 | **MOVIMIENTO DE TIERRAS** | 2d | 2020-05-28 | 2020-05-29 |  | 65d |  | 472.35 |
| 182 | 1.10.1.1 | EXCAVACION MANUAL PARA ZANJAS, H>1.50M | 2d | 2020-05-28 | 2020-05-29 | 172SS | 65d | 0d | 472.35 |
| 183 | 1.10.2 | **CONCRETO SIMPLE** | 1d | 2020-05-30 | 2020-05-30 |  | 65d |  | 357.79 |
| 184 | 1.10.2.1 | SOLADO DE CONCRETO C:H 1/12 E=10 CM | 1d | 2020-05-30 | 2020-05-30 | 182 | 65d | 0d | 357.79 |
| 185 | 1.10.3 | **CONCRETO ARMADO** | 50d | 2020-05-31 | 2020-07-19 |  | 65d |  | 21,203.73 |
| 186 | 1.10.3.1 | **PLATEA DE CIMENTACION** | 8d | 2020-05-31 | 2020-06-07 |  | 65d |  | 2,262.31 |
| 187 | 1.10.3.1.1 | PLATEA DE CIMENTACION, ACERO F'Y=4200 kg/cm2 | 2d | 2020-05-31 | 2020-06-01 | 184 | 65d | 0d | 549.33 |
| 188 | 1.10.3.1.2 | PLATEA DE CIMENTACION, ENCOFRADO Y DESENCOFRADO | 2d | 2020-06-02 | 2020-06-03 | 187 | 65d | 0d | 280.34 |
| 189 | 1.10.3.1.3 | PLATEA DE CIMENTACION, CONCRETO f'c=210 kg/cm² | 2d | 2020-06-04 | 2020-06-05 | 188 | 65d | 0d | 1,413.39 |
| 190 | 1.10.3.1.4 | CURADO QUIMICO DE CONCRETO | 2d | 2020-06-06 | 2020-06-07 | 189 | 107d |  | 19.25 |
| 191 | 1.10.3.2 | **COLUMNAS** | 16d | 2020-06-02 | 2020-06-17 |  | 69d |  | 10,441.67 |
| 192 | 1.10.3.2.1 | COLUMNAS, ACERO F'Y=4200 kg/cm2 | 4d | 2020-06-02 | 2020-06-05 | 187 | 109d |  | 3,597.04 |
| 193 | 1.10.3.2.2 | COLUMNAS, ENCOFRADO Y DESENCOFRADO | 4d | 2020-06-06 | 2020-06-09 | 189 | 65d | 0d | 4,969.11 |
| 194 | 1.10.3.2.3 | COLUMNAS, CONCRETO F'C=210 kg/cm2 | 4d | 2020-06-10 | 2020-06-13 | 193 | 65d | 0d | 1,742.45 |
| 195 | 1.10.3.2.4 | CURADO QUIMICO DE CONCRETO | 4d | 2020-06-14 | 2020-06-17 | 194 | 97d |  | 133.07 |
| 196 | 1.10.3.3 | **VIGAS** | 16d | 2020-06-14 | 2020-06-29 |  | 65d |  | 1,748.74 |
| 197 | 1.10.3.3.1 | VIGAS, ACERO F'Y=4200 kg/cm2 | 4d | 2020-06-14 | 2020-06-17 | 194 | 65d | 0d | 887.04 |
| 198 | 1.10.3.3.2 | VIGAS, ENCOFRADO Y DESENCOFRADO | 4d | 2020-06-18 | 2020-06-21 | 197 | 65d | 0d | 490.59 |
| 199 | 1.10.3.3.3 | VIGAS, CONCRETO f'c=210 kg/cm2 | 4d | 2020-06-22 | 2020-06-25 | 198 | 65d | 0d | 354.11 |
| 200 | 1.10.3.3.4 | CURADO QUIMICO DE CONCRETO | 4d | 2020-06-26 | 2020-06-29 | 199 | 65d | 0d | 17 |
| 201 | 1.10.3.4 | **LOSAS MACIZAS** | 20d | 2020-06-30 | 2020-07-19 |  | 65d |  | 6,751.01 |
| 202 | 1.10.3.4.1 | LOSA MACIZA, ACERO F'Y=4200 kg/cm2 | 5d | 2020-06-30 | 2020-07-04 | 200 | 65d | 0d | 2,414.04 |
| 203 | 1.10.3.4.2 | LOSA MACIZA, ENCOFRADO Y DESENCOFRADO | 5d | 2020-07-05 | 2020-07-09 | 202 | 65d | 0d | 2,209.03 |
| 204 | 1.10.3.4.3 | LOSA MACIZA, CONCRETO F'C=210 kg/cm2 | 5d | 2020-07-10 | 2020-07-14 | 203 | 65d | 0d | 2,055.44 |
| 205 | 1.10.3.4.4 | CURADO QUIMICO DE CONCRETO | 5d | 2020-07-15 | 2020-07-19 | 204 | 65d |  | 72.5 |

| ID | WBS | Task | Duration | Start | Finish | Predecessors | Total slack | Free slack | Cost |
| --- | --- | --- | --- | --- | --- | --- | --- | --- | --- |
| 206 | 1.11 | **OBRAS EXTERIORES** | 7d | 2020-08-03 | 2020-08-09 |  | 40d | 0d | 127,185.17 |
| 207 | 1.11.1 | **OBRAS PRELIMINARES** | 1d | 2020-08-03 | 2020-08-03 |  | 40d |  | 836.28 |
| 208 | 1.11.1.1 | TRAZO DE NIVELES Y REPLANTEO | 1d | 2020-08-03 | 2020-08-03 | 222 | 40d | 0d | 836.28 |
| 209 | 1.11.2 | **MOVIMIENTO DE TIERRAS** | 3d | 2020-08-04 | 2020-08-06 |  | 40d | 0d | 48,220.36 |
| 210 | 1.11.2.1 | EXCAVACION DE ZANJAS PARA UÑAS DE PATIOS, VEREDAS Y SARDINELES | 1d | 2020-08-04 | 2020-08-04 | 208 | 40d | 0d | 8,739.13 |
| 211 | 1.11.2.2 | AFIRMADO PARA PISOS, PATIOS Y VEREDAS | 2d | 2020-08-05 | 2020-08-06 | 210 | 43d |  | 29,777.68 |
| 212 | 1.11.2.3 | ACARREO INTERNO, MATERIAL PROCEDENTE DE EXCAVACIONES | 1d | 2020-08-05 | 2020-08-05 | 210 | 43d | 0d | 3,831.24 |
| 213 | 1.11.2.4 | ELIMINACION DE MATERIAL EXCEDENTE DP=5KM | 1d | 2020-08-06 | 2020-08-06 | 212 | 43d |  | 5,872.31 |
| 214 | 1.11.3 | **CONCRETO SIMPLE** | 2d | 2020-08-07 | 2020-08-08 |  | 43d | 0d | 74,496.33 |
| 215 | 1.11.3.1 | CONCRETO PARA LOSA DE PATIOS Y VEREDAS F'C= 175 KG/CM2 E=0.10M | 1d | 2020-08-08 | 2020-08-08 | 216 | 43d |  | 58,681.77 |
| 216 | 1.11.3.2 | CONCRETO PARA UÑAS F'C= 175 KG/CM2 | 1d | 2020-08-07 | 2020-08-07 | 209 | 43d | 0d | 7,431 |
| 217 | 1.11.3.3 | JUNTA DE DILATACION RELLENO CON MORTERO ASFALTICO E=1" | 1d | 2020-08-08 | 2020-08-08 | 216 | 43d |  | 5,818.97 |
| 218 | 1.11.3.4 | CURADO QUIMICO DE CONCRETO | 1d | 2020-08-08 | 2020-08-08 | 216 | 43d |  | 2,564.59 |
| 219 | 1.11.4 | **VARIOS** | 1d | 2020-08-09 | 2020-08-09 |  | 43d | 0d | 3,632.2 |
| 220 | 1.11.4.1 | ASTA DE BANDERA TIPICO | 1d | 2020-08-09 | 2020-08-09 | 214 | 43d | 0d | 819.54 |
| 221 | 1.11.4.2 | LIMPIEZA FINAL | 1d | 2020-08-09 | 2020-08-09 | 220SS | 43d |  | 2,812.66 |
| 222 | 1.12 | **TECHADO DE PATIO DE JUEGOS Y DE FORMACION** | 25d | 2020-07-09 | 2020-08-02 |  | 40d | 0d | 155,248.04 |
| 223 | 1.12.1 | **OBRAS PRELIMINARES** | 3d | 2020-07-09 | 2020-07-11 |  | 53d |  | 2,176.97 |
| 224 | 1.12.1.1 | TRAZO DE NIVELES Y REPLANTEO | 1d | 2020-07-09 | 2020-07-09 | 159FS-45d | 53d | 0d | 53.7 |
| 225 | 1.12.1.2 | EXCAVACION MANUAL PARA ZANJAS | 1d | 2020-07-10 | 2020-07-10 | 224 | 53d | 0d | 1,024.1 |
| 226 | 1.12.1.3 | SOLADO DE CONCRETO C:H 1/12 E=10 CM | 1d | 2020-07-11 | 2020-07-11 | 225 | 53d | 0d | 1,099.17 |
| 227 | 1.12.2 | **CONCRETO ARMADO** | 3d | 2020-07-12 | 2020-07-14 |  | 53d | 0d | 5,309.4 |
| 228 | 1.12.2.1 | **ZAPATAS** | 3d | 2020-07-12 | 2020-07-14 |  | 53d |  | 5,309.4 |
| 229 | 1.12.2.1.1 | ZAPATAS, ACERO F'Y=4200 kg/cm2 | 1d | 2020-07-12 | 2020-07-12 | 226 | 53d | 0d | 1,247.89 |
| 230 | 1.12.2.1.2 | ZAPATAS, CONCRETO f'c=210 kg/cm² | 1d | 2020-07-13 | 2020-07-13 | 229 | 53d | 0d | 4,025.45 |
| 231 | 1.12.2.1.3 | CURADO QUIMICO DE CONCRETO | 1d | 2020-07-14 | 2020-07-14 | 230 | 53d |  | 36.06 |

| ID | WBS | Task | Duration | Start | Finish | Predecessors | Total slack | Free slack | Cost |
| --- | --- | --- | --- | --- | --- | --- | --- | --- | --- |
| 232 | 1.12.3 | **ESTRUCTURAS METALICAS** | 19d | 2020-07-15 | 2020-08-02 |  | 40d |  | 147,761.67 |
| 233 | 1.12.3.1 | **PERNOS DE ANCLAJE** | 1d | 2020-07-15 | 2020-07-15 | 227 | 53d | 0d | 3,694.8 |
| 234 | 1.12.3.1.1 | SUMINISTRO, HABILITACION Y MONTAJE DE PERNOS DE ANCLAJE PRE INSTALADOS, L= 0.50m, Ø 3/4", EN A325. | 1d | 2020-07-15 | 2020-07-15 |  | 53d |  | 3,694.8 |
| 235 | 1.12.3.2 | **COLUMNA METALICA** | 1d | 2020-07-16 | 2020-07-16 | 233 | 53d | 0d | 27,317.6 |
| 236 | 1.12.3.2.1 | SUMINISTRO Y HABILITACION DE COLUMNA METALICA, H=5.15 M, TC 300X300X4 mm, A500 | 1d | 2020-07-16 | 2020-07-16 |  | 53d |  | 18,419.2 |
| 237 | 1.12.3.2.2 | PINTADO DE COLUMNA METALICA , H=5.15 M, TC 300X300X4mm, A500 | 1d | 2020-07-16 | 2020-07-16 |  | 53d |  | 1,924.2 |
| 238 | 1.12.3.2.3 | MONTAJE DE COLUMNA METALICA, H=5.15 M, TC 300X300X4 mm , A500 | 1d | 2020-07-16 | 2020-07-16 |  | 53d |  | 6,974.2 |
| 239 | 1.12.3.3 | **VIGA METALICA** | 1d | 2020-07-17 | 2020-07-17 | 235 | 53d | 0d | 53,367.79 |
| 240 | 1.12.3.3.1 | SUMINISTRO Y HABILITACION DE VIGA METALICA TC 200X200X3 mm, A50 | 1d | 2020-07-17 | 2020-07-17 |  | 53d |  | 17,095.3 |
| 241 | 1.12.3.3.2 | PINTADO DE VIGA METALICA TC 200X200X3 mm, A50 | 1d | 2020-07-17 | 2020-07-17 |  | 53d |  | 23,917.03 |
| 242 | 1.12.3.3.3 | MONTAJE DE VIGA METALICA TC 200X200X3 mm, A50 | 1d | 2020-07-17 | 2020-07-17 |  | 53d |  | 12,355.46 |
| 243 | 1.12.3.4 | **TIJERAL PARABOLICO** | 2d | 2020-07-19 | 2020-07-20 | 255 | 53d | 0d | 22,481.25 |
| 244 | 1.12.3.4.1 | SUMINISTRO Y HABILITACION DE TIJERALE PARABOLICO TIPO CAJON DE .20X.30 CON BRIDAS DE L 1 1/2"X1 1/2"X3/16", LONG. 9.64m | 2d | 2020-07-19 | 2020-07-20 |  | 53d |  | 17,201.25 |
| 245 | 1.12.3.4.2 | PINTADO DE TIJERALE PARABOLICO TIPO CAJON DE .20X.30 CON BRIDAS DE L 1 1/2"X1 1/2"X3/16", LONG. 9.64m | 2d | 2020-07-19 | 2020-07-20 |  | 53d |  | 2,490.3 |
| 246 | 1.12.3.4.3 | MONTAJE DE TIJERALE PARABOLICO TIPO CAJON DE .20X.30 CON BRIDAS DE L 1 1/2"X1 1/2"X3/16", LONG. 9.64m | 1d | 2020-07-19 | 2020-07-19 |  | 54d |  | 2,789.7 |
| 247 | 1.12.3.5 | **VIGUETAS METALICAS** | 1d | 2020-07-22 | 2020-07-22 | 264 | 40d | 0d | 12,841.68 |
| 248 | 1.12.3.5.1 | SUMINISTRO Y HABILITACION DE VIGUETAS METALICAS DE TR 80X40X2.5mm, EN A500. | 1d | 2020-07-22 | 2020-07-22 |  | 40d |  | 4,250.4 |
| 249 | 1.12.3.5.2 | PINTADO DE VIGUETAS METALICAS DE TR 80X40X2.5mm, EN A500. | 1d | 2020-07-22 | 2020-07-22 |  | 40d |  | 2,995.3 |
| 250 | 1.12.3.5.3 | MONTAJE DE VIGUETAS METALICAS DE TR 80X40X2.5mm, EN A500. | 1d | 2020-07-22 | 2020-07-22 |  | 40d |  | 5,595.98 |
| 251 | 1.12.3.6 | **CRUCES DE SAN ANDRES** | 2d | 2020-07-23 | 2020-07-24 | 247 | 40d | 0d | 1,533 |
| 252 | 1.12.3.6.1 | SUMINISTRO Y HABILITACION DE CRUZ DE SAN ANDRES, Ø 5/8". CON LONG > 4m Y < 5m | 2d | 2020-07-23 | 2020-07-24 |  | 40d |  | 647.7 |
| 253 | 1.12.3.6.2 | PINTADO DE CRUZ DE SAN ANDRES, Ø 5/8". CON LONG > 4m Y < 5m | 2d | 2020-07-23 | 2020-07-24 |  | 40d |  | 189 |
| 254 | 1.12.3.6.3 | MONTAJE DE CRUZ DE SAN ANDRES, Ø 5/8". CON LONG > 4m Y < 5m | 2d | 2020-07-23 | 2020-07-24 |  | 40d |  | 696.3 |
| 255 | 1.12.3.7 | **APOYOS DE TIJERALES** | 1d | 2020-07-18 | 2020-07-18 | 239 | 53d | 0d | 4,335.2 |
| 256 | 1.12.3.7.1 | SUMINISTRO Y HABILITACION DE APOYO DE TIJERAL, DE PLANCHA DE 250X250X12mm, EN A36. | 1d | 2020-07-18 | 2020-07-18 |  | 53d |  | 2,847.7 |
| 257 | 1.12.3.7.2 | PINTADO DE APOYO DE TIJERAL, DE PLANCHA DE 250X250X12mm, EN A36. | 1d | 2020-07-18 | 2020-07-18 |  | 53d |  | 629.4 |
| 258 | 1.12.3.7.3 | MONTAJE DE APOYO DE TIJERAL, DE PLANCHA DE 250X250X12mm, EN A36. | 1d | 2020-07-18 | 2020-07-18 |  | 53d |  | 858.1 |

| ID | WBS | Task | Duration | Start | Finish | Predecessors | Total slack | Free slack | Cost |
| --- | --- | --- | --- | --- | --- | --- | --- | --- | --- |
| 259 | 1.12.3.8 | **CANALETA DE EVACUACION PLUVIAL** | 5d | 2020-07-29 | 2020-08-02 | 262 | 40d |  | 1,831.2 |
| 260 | 1.12.3.8.1 | SUMINISTRO Y HABILITACION, CANALETA DE PLANCHA GALVANIZADA E=1/20". | 5d | 2020-07-29 | 2020-08-02 |  | 40d |  | 973.35 |
| 261 | 1.12.3.8.2 | MONTAJE, CANALETA DE PLANCHA GALVANIZADA E=1/20". | 1d | 2020-07-29 | 2020-07-29 |  | 44d |  | 857.85 |
| 262 | 1.12.3.9 | **MONTANTE DE EVACUACION PLUVIAL** | 2d | 2020-07-27 | 2020-07-28 | 268 | 40d | 0d | 2,545.95 |
| 263 | 1.12.3.9.1 | SUMINISTRO, HABILITACION Y MONTAJE DE MONTANTE DE EVACUACION PLUVIAL, TUBO PVC PN 10, 6" DIAMETRO. | 2d | 2020-07-27 | 2020-07-28 |  | 40d |  | 2,545.95 |
| 264 | 1.12.3.10 | **ANGULO DE RESPALDO DE VIGUETAS** | 2d | 2020-07-20 | 2020-07-21 | 243SS+1d | 40d | 0d | 6,750.7 |
| 265 | 1.12.3.10.1 | SUMINISTRO Y HABILITACION DE ANGULOS DE RESPALDO, L2X2X3/16", EN A36, LONG. 0.20m | 2d | 2020-07-20 | 2020-07-21 |  | 40d |  | 3,642.1 |
| 266 | 1.12.3.10.2 | PINTADO DE ANGULOS DE RESPALDO, L2X2X3/16", EN A36, LONG. 0.20m | 2d | 2020-07-20 | 2020-07-21 |  | 40d |  | 899.8 |
| 267 | 1.12.3.10.3 | MONTAJE DE ANGULOS DE RESPALDO, L2X2X3/16", EN A36, LONG. 0.20m | 2d | 2020-07-20 | 2020-07-21 |  | 40d |  | 2,208.8 |
| 268 | 1.12.3.11 | **COBERTURAS LIVIANAS** | 2d | 2020-07-25 | 2020-07-26 | 251 | 40d | 0d | 8,848.32 |
| 269 | 1.12.3.11.1 | SUMINISTRO DE CALAMINON CURVO PREPINTADO, ALUZINC E=0.45mm. | 1d | 2020-07-25 | 2020-07-25 |  | 41d |  | 6,199.73 |
| 270 | 1.12.3.11.2 | MONTAJE DE CALAMINON CURVO PREPINTADO, ALUZINC E=0.45mm. | 2d | 2020-07-25 | 2020-07-26 |  | 40d |  | 2,648.59 |
| 271 | 1.12.3.12 | **ANGULO DE BORDE** | 1d | 2020-07-18 | 2020-07-18 | 239 | 55d |  | 2,214.18 |
| 272 | 1.12.3.12.1 | SUMINISTRO Y HABILITACION DE ANGULOS DE BORDE, L3X3X3/16", EN A36, 9.64m | 1d | 2020-07-18 | 2020-07-18 |  | 55d |  | 1,204.54 |
| 273 | 1.12.3.12.2 | PINTADO DE ANGULOS DE BORDE, L3X3X3/16", EN A36, 9.64m | 1d | 2020-07-18 | 2020-07-18 |  | 55d |  | 453.78 |
| 274 | 1.12.3.12.3 | MONTAJE DE ANGULOS DE BORDE, L3X3X3/16", EN A36, 9.64m | 1d | 2020-07-18 | 2020-07-18 |  | 55d |  | 555.86 |
| 275 | 1.13 | **SISTEMA DE DRENAJE PLUVIAL** | 10d | 2020-08-04 | 2020-08-13 |  | 40d |  | 64,933.5 |
| 276 | 1.13.1 | EXCAVACION DE ZANJAS PARA DRENAJE PLUVIAL | 1d | 2020-08-04 | 2020-08-04 | 210SS | 40d | 0d | 2,741.42 |
| 277 | 1.13.2 | ELIMINACION DE MATERIAL EXCEDENTE DP=5KM | 1d | 2020-08-05 | 2020-08-05 | 276 | 48d |  | 2,100.72 |
| 278 | 1.13.3 | REFINE Y NIVELACION DE FONDO DE ZANJA | 1d | 2020-08-05 | 2020-08-05 | 276 | 40d | 0d | 481.15 |
| 279 | 1.13.4 | ACERO FY=4,200 KG/CM2 PARA CUNETAS | 1d | 2020-08-08 | 2020-08-08 | 280 | 40d | 0d | 4,265.35 |
| 280 | 1.13.5 | ENCOFRADO Y DESENCOFRADO DE CUNETAS REVESTIDA | 2d | 2020-08-06 | 2020-08-07 | 278 | 40d | 0d | 9,015.13 |
| 281 | 1.13.6 | CUNETAS, CONCRETO F´C=210 KG/CM2 SEGUN DISEÑO | 1d | 2020-08-09 | 2020-08-09 | 279 | 40d | 0d | 11,449.94 |
| 282 | 1.13.7 | CURADO QUIMICO PARA LOSA | 1d | 2020-08-10 | 2020-08-10 | 281 | 40d | 0d | 538.49 |
| 283 | 1.13.8 | JUNTA DE DILATACION RELLENO CON MORTERO ASFALTICO E=1" | 1d | 2020-08-11 | 2020-08-11 | 282 | 40d | 0d | 122.05 |
| 284 | 1.13.9 | REJILLA METALICA SEGUN DISEÑO | 2d | 2020-08-12 | 2020-08-13 | 283 | 40d |  | 34,219.25 |

| ID | WBS | Task | Duration | Start | Finish | Predecessors | Total slack | Free slack | Cost |
| --- | --- | --- | --- | --- | --- | --- | --- | --- | --- |
| 285 | 2 | **ARQUITECTURA** | 112d | 2020-06-03 | 2020-09-22 |  | 0d |  | 1,054,289.9 |
| 286 | 2.1 | **CERCO PERIMETRICO** | 25d | 2020-06-11 | 2020-07-05 |  | 79d |  | 72,324.02 |
| 287 | 2.1.1 | **MURO DE TABIQUES Y ALBAÑILERIA** | 7d | 2020-06-11 | 2020-06-17 |  | 79d |  | 42,318.29 |
| 288 | 2.1.1.1 | MUROS DE LADRILLO KK CARAVISTA TIPO IV SOGA M:1:4 E=1.0 CM. | 7d | 2020-06-11 | 2020-06-17 | 59 | 79d | 0d | 42,318.29 |
| 289 | 2.1.2 | **REVOQUES ENLUCIDOS Y MOLDURAS** | 4d | 2020-06-29 | 2020-07-02 |  | 79d | 0d | 18,124.75 |
| 290 | 2.1.2.1 | TARRAJEO DE SOBRECIMIENTOS | 4d | 2020-06-29 | 2020-07-02 | 66 | 79d |  | 3,130.36 |
| 291 | 2.1.2.2 | TARRAJEO DE SUPERFICIE DE COLUMNAS | 4d | 2020-06-29 | 2020-07-02 | 66 | 79d |  | 6,883.79 |
| 292 | 2.1.2.3 | TARRAJEO DE SUPERFICIE DE VIGAS | 4d | 2020-06-29 | 2020-07-02 | 66 | 79d |  | 8,110.6 |
| 293 | 2.1.3 | **PINTURA** | 3d | 2020-07-03 | 2020-07-05 |  | 79d |  | 11,880.98 |
| 294 | 2.1.3.1 | PINTURA LATEX 2 MANOS EN MUROS | 3d | 2020-07-03 | 2020-07-05 | 289 | 79d |  | 7,483.44 |
| 295 | 2.1.3.2 | PINTURA LATEX 2 MANOS EN COLUMNAS | 3d | 2020-07-03 | 2020-07-05 | 289 | 79d |  | 2,364.28 |
| 296 | 2.1.3.3 | PINTURA LATEX 2 MANOS EN VIGAS | 2d | 2020-07-03 | 2020-07-04 | 289 | 80d |  | 2,033.26 |
| 297 | 2.2 | **PORTADA DE INGRESO** | 13d | 2020-07-31 | 2020-08-12 |  | 41d |  | 11,741.88 |
| 298 | 2.2.1 | **REVOQUES ENLUCIDOS Y MOLDURAS** | 4d | 2020-08-08 | 2020-08-11 |  | 41d |  | 2,822.64 |
| 299 | 2.2.1.1 | TARRAJEO DE SUPERFICIE DE COLUMNAS | 2d | 2020-08-08 | 2020-08-09 | 86 | 43d | 0d | 1,597.73 |
| 300 | 2.2.1.2 | TARRAJEO DE SUPERFICIE DE VIGAS | 1d | 2020-08-11 | 2020-08-11 | 91 | 41d | 0d | 1,224.91 |
| 301 | 2.2.2 | **CARPINTERIA METALICA** | 3d | 2020-07-31 | 2020-08-02 |  | 51d |  | 7,590.53 |
| 302 | 2.2.2.1 | PUERTA DE METAL S/DISEÑO, INC. PINTURA Y COLOCACION | 3d | 2020-07-31 | 2020-08-02 | 222FF | 51d | 0d | 7,590.53 |
| 303 | 2.2.3 | **CERRAJERIA** | 1d | 2020-08-02 | 2020-08-02 |  | 51d |  | 472.88 |
| 304 | 2.2.3.1 | BISAGRA DE FIERRO DE 5/8 X 6" | 1d | 2020-08-02 | 2020-08-02 | 302FF | 51d |  | 229.68 |
| 305 | 2.2.3.2 | CERRADURA 3 GOLPES EN PUERTA , CON TIRADOR | 1d | 2020-08-02 | 2020-08-02 | 302FF | 51d |  | 243.2 |
| 306 | 2.2.4 | **PINTURA** | 3d | 2020-08-10 | 2020-08-12 |  | 41d |  | 855.83 |
| 307 | 2.2.4.1 | PINTURA LATEX 2 MANOS EN COLUMNAS | 1d | 2020-08-12 | 2020-08-12 | 300 | 41d |  | 548.75 |
| 308 | 2.2.4.2 | PINTURA LATEX 2 MANOS EN VIGAS | 1d | 2020-08-10 | 2020-08-10 | 299 | 43d |  | 307.08 |

| ID | WBS | Task | Duration | Start | Finish | Predecessors | Total slack | Free slack | Cost |
| --- | --- | --- | --- | --- | --- | --- | --- | --- | --- |
| 309 | 2.3 | **MODULOS** | 100d | 2020-06-15 | 2020-09-22 |  | 0d |  | 964,153.77 |
| 310 | 2.3.1 | **MURO DE TABIQUES Y ALBAÑILERIA** | 47d | 2020-06-15 | 2020-07-31 |  | 0d |  | 86,501.63 |
| 311 | 2.3.1.1 | MUROS DE LADRILLO KK TIPO IV SOGA M:1:1:4 E=1.5 CM. | 47d | 2020-06-15 | 2020-07-31 | 133 | 0d |  | 35,241.63 |
| 312 | 2.3.1.2 | MURO DE LADRILLO DE KK TIPO IV CABEZA M:1:4 E=1.0 cm | 45d | 2020-06-15 | 2020-07-29 | 133 | 55d |  | 51,260 |
| 313 | 2.3.2 | **REVOQUES ENLUCIDOS Y MOLDURAS** | 60d | 2020-07-07 | 2020-09-04 |  | 0d |  | 262,152.52 |
| 314 | 2.3.2.1 | TARRAJEO PRIMARIO C/MORTERO 1:5 | 45d | 2020-07-07 | 2020-08-20 | 311FS-25d | 0d |  | 73,745.98 |
| 315 | 2.3.2.2 | TARRAJEO DE SOBRECIMIENTOS | 40d | 2020-07-12 | 2020-08-20 | 314FS-40d | 0d |  | 2,892.1 |
| 316 | 2.3.2.3 | TARRAJEO EN MUROS INTERIOR Y EXTERIOR | 45d | 2020-07-12 | 2020-08-25 | 314FS-40d, 315FS-40d | 0d |  | 66,821.51 |
| 317 | 2.3.2.4 | TARRAJEO DE SUPERFICIE DE COLUMNAS | 45d | 2020-07-17 | 2020-08-30 | 316FS-40d | 0d |  | 38,596.5 |
| 318 | 2.3.2.5 | TARRAJEO DE SUPERFICIE DE VIGAS | 35d | 2020-08-01 | 2020-09-04 | 317FS-30d | 1d | 0d | 42,925.44 |
| 319 | 2.3.2.6 | VESTIDURA DE DERRAMES | 45d | 2020-07-17 | 2020-08-30 | 316FS-40d | 10d | 0d | 8,425.36 |
| 320 | 2.3.2.7 | BRUÑAS DEGUN DETALLE | 45d | 2020-07-17 | 2020-08-30 | 316FS-40d | 23d |  | 28,745.63 |
| 321 | 2.3.3 | **PISOS Y PAVIMENTOS** | 55d | 2020-07-24 | 2020-09-16 |  | 6d |  | 77,236.53 |
| 322 | 2.3.3.1 | CONTRAPISO DE 2" | 40d | 2020-07-24 | 2020-09-01 | 164FS-30d | 6d | 0d | 28,065.07 |
| 323 | 2.3.3.2 | PISO CERAMICO 45 x 45 COLOR ANTIDESLIZANTE | 35d | 2020-08-03 | 2020-09-06 | 322FS-30d | 6d | 0d | 45,934.13 |
| 324 | 2.3.3.3 | PISO CERAMICO 30 x 30 SERIE COLOR - NACIONAL | 40d | 2020-08-08 | 2020-09-16 | 323FS-30d | 6d |  | 3,237.33 |
| 325 | 2.3.4 | **ZOCALOS Y CONTRAZOCALOS** | 50d | 2020-07-12 | 2020-08-30 |  | 23d |  | 33,504.76 |
| 326 | 2.3.4.1 | CONTRAZOCALOS DE PORCELANATO H=0.20M | 45d | 2020-07-12 | 2020-08-25 | 315FS-40d | 28d |  | 21,398.36 |
| 327 | 2.3.4.2 | ZOCALO PORCELANATO 60X60CM | 45d | 2020-07-17 | 2020-08-30 | 316FS-40d | 23d |  | 12,106.4 |
| 328 | 2.3.5 | **CIELO RASOS** | 30d | 2020-08-11 | 2020-09-09 |  | 1d |  | 64,630.79 |
| 329 | 2.3.5.1 | CIELO RASO CON MEZCLA C:A 1:4 | 30d | 2020-08-11 | 2020-09-09 | 318FS-25d | 1d | 0d | 64,630.79 |
| 330 | 2.3.6 | **COBERTURAS Y CUBIERTAS** | 31d | 2020-08-23 | 2020-09-22 |  | 0d |  | 146,022.75 |
| 331 | 2.3.6.1 | COBERTURA CON PLANCHA TERMOACUSTICA CON CALAMINON | 14d | 2020-08-23 | 2020-09-05 | 159 | 0d |  | 140,541.38 |
| 332 | 2.3.6.2 | SUMINISTRO Y COLOCACION DE CANALETA AEREA METALICA | 10d | 2020-09-06 | 2020-09-15 | 331 | 0d |  | 4,281.37 |
| 333 | 2.3.6.3 | MONTANTE DE PVC DE 4",CON 2 COLUMNETAS DE C° DE 15x15 CM. | 7d | 2020-09-16 | 2020-09-22 | 332 | 0d |  | 1,200 |

| ID | WBS | Task | Duration | Start | Finish | Predecessors | Total slack | Free slack | Cost |
| --- | --- | --- | --- | --- | --- | --- | --- | --- | --- |
| 334 | 2.3.7 | **CARPINTERIA DE MADERA** | 10d | 2020-08-31 | 2020-09-09 |  | 0d |  | 148,801.04 |
| 335 | 2.3.7.1 | PUERTA DE MADERA S/DISEÑO, INC./PINTURA Y COLOCACION | 8d | 2020-08-31 | 2020-09-07 | 317 | 0d |  | 58,446.58 |
| 336 | 2.3.7.2 | VENTANA DE MADERA S/DISEÑO , INC /PINTURA Y COLOCACION | 10d | 2020-08-31 | 2020-09-09 | 319 | 10d | 0d | 90,354.46 |
| 337 | 2.3.8 | **CERRAJERIA** | 8d | 2020-09-03 | 2020-09-10 |  | 12d |  | 59,806.64 |
| 338 | 2.3.8.1 | BISAGRA DE FIERRO DE 4" | 3d | 2020-09-05 | 2020-09-07 | 335FF | 15d |  | 19,846.64 |
| 339 | 2.3.8.2 | BISAGRA ALUMINIZADA CAPUCHINA DE 3" X 3" | 3d | 2020-09-08 | 2020-09-10 | 335 | 12d |  | 330.56 |
| 340 | 2.3.8.3 | CERRADURA 3 GOLPES EN PUERTA, CON TIRADOR | 3d | 2020-09-05 | 2020-09-07 | 335FF | 15d |  | 12,768 |
| 341 | 2.3.8.4 | CERROJO TIPO SAPITO SEGURIDAD BATIENTES PARA VENTANAS | 5d | 2020-09-03 | 2020-09-07 | 335FF | 15d |  | 26,861.44 |
| 342 | 2.3.9 | **VIDRIOS, CRISTALES Y SIMILARES** | 3d | 2020-09-10 | 2020-09-12 |  | 10d |  | 3,016.67 |
| 343 | 2.3.9.1 | VIDRIOS SEMIDOBLES IMPORTADO SUMINISTRO Y COLOCACION | 3d | 2020-09-10 | 2020-09-12 | 336 | 10d |  | 3,016.67 |
| 344 | 2.3.10 | **PINTURA** | 33d | 2020-08-21 | 2020-09-22 |  | 0d |  | 74,645.72 |
| 345 | 2.3.10.1 | PINTURA LATEX 2 MANOS EN MUROS Y COLUMNA | 12d | 2020-09-10 | 2020-09-21 | 329 | 1d |  | 40,886.78 |
| 346 | 2.3.10.2 | PINTURA LATEX 2 MANOS EN CIELO RASO Y VIGAS | 20d | 2020-08-21 | 2020-09-09 | 315 | 13d |  | 31,554.91 |
| 347 | 2.3.10.3 | PINTURA BARNIZ EN PUERTAS DE MADERA (2 MANOS) | 15d | 2020-09-08 | 2020-09-22 | 335 | 0d |  | 2,204.03 |
| 348 | 2.3.11 | **VARIOS** | 34d | 2020-08-10 | 2020-09-12 |  | 10d |  | 7,834.72 |
| 349 | 2.3.11.1 | JUNTA D/DILATAC.C/ESPUMA PLASTICA+JEBE MICROPOROSO EN VENTANAS | 3d | 2020-09-10 | 2020-09-12 | 336 | 10d |  | 6,738.21 |
| 350 | 2.3.11.2 | PLACA RECORDATORIA DE MARMOL 0.80X0.60M | 1d | 2020-08-10 | 2020-08-10 | 219 | 43d |  | 1,096.51 |
| 351 | 2.4 | **CISTERNA Y TANQUE ELEVADO** | 6d | 2020-06-03 | 2020-06-08 |  | 106d |  | 6,070.23 |
| 352 | 2.4.1 | **REVOQUES ENLUCIDOS Y MOLDURAS** | 3d | 2020-06-03 | 2020-06-05 |  | 106d | 0d | 5,225.23 |
| 353 | 2.4.1.1 | TARRAJEO PRIMARIO C/MORTERO 1:5 | 2d | 2020-06-03 | 2020-06-04 | 175 | 107d |  | 707.27 |
| 354 | 2.4.1.2 | TARRAJEO EN MUROS INTERIORES Y EXTERIORES C:A 1:5 CON IMPERMEABILIZANTE | 3d | 2020-06-03 | 2020-06-05 | 175 | 106d |  | 2,881.41 |
| 355 | 2.4.1.3 | TARRAJEO DE SUPERFICIE DE COLUMNAS | 3d | 2020-06-03 | 2020-06-05 | 175 | 106d |  | 1,111.32 |
| 356 | 2.4.1.4 | TARRAJEO DE SUPERFICIE DE VIGAS | 3d | 2020-06-03 | 2020-06-05 | 175 | 106d |  | 525.23 |
| 357 | 2.4.2 | **PINTURA** | 3d | 2020-06-06 | 2020-06-08 |  | 106d |  | 845 |
| 358 | 2.4.2.1 | PINTURA LATEX 2 MANOS EN COLUMNAS | 3d | 2020-06-06 | 2020-06-08 | 352 | 106d |  | 708.71 |
| 359 | 2.4.2.2 | PINTURA LATEX 2 MANOS EN VIGAS | 3d | 2020-06-06 | 2020-06-08 | 352 | 106d |  | 136.29 |

| ID | WBS | Task | Duration | Start | Finish | Predecessors | Total slack | Free slack | Cost |
| --- | --- | --- | --- | --- | --- | --- | --- | --- | --- |
| 360 | 3 | **INSTALACIONES SANITARIAS** | 57d | 2020-07-01 | 2020-08-26 |  | 32d |  | 50,302.57 |
| 361 | 3.1 | **TRABAJOS PRELIMINARES** | 1d | 2020-07-05 | 2020-07-06 |  | 84d |  | 64.26 |
| 362 | 3.1.1 | TRAZO DE NIVELES Y REPLANTEO | 1d | 2020-07-05 | 2020-07-06 | 118SF | 84d |  | 64.26 |
| 363 | 3.2 | **APARATOS SANITARIOS** | 4d | 2020-08-23 | 2020-08-26 |  | 32d |  | 7,821.64 |
| 364 | 3.2.1 | INODORO LOSA BLANCO | 1d | 2020-08-23 | 2020-08-23 | 159 | 35d |  | 3,294.88 |
| 365 | 3.2.2 | URINARIO LOSA BLANCA | 2d | 2020-08-23 | 2020-08-24 | 159 | 34d |  | 609.84 |
| 366 | 3.2.3 | LAVATORIO DE LOSA BLANCA | 1d | 2020-08-23 | 2020-08-23 | 159 | 35d |  | 800 |
| 367 | 3.2.4 | LAVADERO DE ALUMINIO P/COCINA | 2d | 2020-08-23 | 2020-08-24 | 159 | 34d |  | 202.54 |
| 368 | 3.2.5 | LAVADERO P/CUARTO DE LIMPIEZA | 2d | 2020-08-23 | 2020-08-24 | 159 | 34d |  | 100 |
| 369 | 3.2.6 | DUCHA | 2d | 2020-08-24 | 2020-08-25 | 159FS+1d | 33d |  | 559 |
| 370 | 3.2.7 | LLAVE ESFERICA PARA JARDIN 1/2" | 2d | 2020-08-24 | 2020-08-25 | 159FS+1d | 33d |  | 81.09 |
| 371 | 3.2.8 | PAPELERA DE LOSA BLANCA | 2d | 2020-08-24 | 2020-08-25 | 159FS+1d | 33d |  | 209.52 |
| 372 | 3.2.9 | COLOCACION DE APARATOS SANITARIOS | 2d | 2020-08-24 | 2020-08-25 | 159FS+1d | 33d |  | 1,758.85 |
| 373 | 3.2.10 | COLOCACION DE ACCESORIOS SANITARIOS | 3d | 2020-08-24 | 2020-08-26 | 159FS+1d | 32d |  | 205.92 |
| 374 | 3.3 | **SISTEMA DE AGUA** | 32d | 2020-07-04 | 2020-08-04 |  | 54d |  | 8,502.02 |
| 375 | 3.3.1 | **SISTEMA DE AGUA FRIA** | 4d | 2020-08-01 | 2020-08-04 |  | 54d |  | 2,816.48 |
| 376 | 3.3.1.1 | SALIDA DE AGUA FRIA 1/2" | 4d | 2020-08-01 | 2020-08-04 | 311 | 54d |  | 2,816.48 |
| 377 | 3.3.2 | **MOVIMIENTO DE TIERRAS** | 2d | 2020-07-04 | 2020-07-06 |  | 84d |  | 1,646.47 |
| 378 | 3.3.2.1 | EXCAVACION DE ZANJAS PARA TUBERIA | 2d | 2020-07-04 | 2020-07-06 | 118SF | 84d |  | 732.85 |
| 379 | 3.3.2.2 | REFINE Y NIVELACION DE FONDO DE ZANJA | 1d | 2020-07-05 | 2020-07-06 | 118SF | 84d |  | 243.78 |
| 380 | 3.3.2.3 | RELLENO Y COMPACTACION DE ZANJAS | 1d | 2020-07-05 | 2020-07-06 | 118SF | 84d |  | 669.84 |
| 381 | 3.3.3 | **RED DE DISTRIBUCION AGUA POTABLE** | 16d | 2020-07-05 | 2020-07-20 |  | 69d |  | 4,039.07 |
| 382 | 3.3.3.1 | TUBERIA PVC SAP D=1/2" | 1d | 2020-07-05 | 2020-07-06 | 118SF | 84d |  | 619.19 |
| 383 | 3.3.3.2 | TUBERIA PVC SAP D=3/4" | 1d | 2020-07-05 | 2020-07-06 | 118SF | 84d |  | 1,148.16 |
| 384 | 3.3.3.3 | ACCESORIOS RED DE DISTRIBUCION DE AGUA | 1d | 2020-07-20 | 2020-07-20 | 180 | 68d | 0d | 405.97 |
| 385 | 3.3.3.4 | ACCESORIOS Y TUBERIA DE AGUA TANQUE ELEVADO Y CISTERNA | 1d | 2020-07-20 | 2020-07-20 | 180 | 69d |  | 1,123.04 |
| 386 | 3.3.3.5 | PRUEBA HIDRAULICA PARA TUBERIA DE AGUA | 1d | 2020-07-05 | 2020-07-06 | 118SF | 84d |  | 742.71 |

| ID | WBS | Task | Duration | Start | Finish | Predecessors | Total slack | Free slack | Cost |
| --- | --- | --- | --- | --- | --- | --- | --- | --- | --- |
| 387 | 3.4 | **SISTEMA DE DESAGUE** | 53d | 2020-07-01 | 2020-08-22 |  | 32d | 0d | 26,387.37 |
| 388 | 3.4.1 | **SALIDA DE DESAGUE Y VENTILACION** | 52d | 2020-07-02 | 2020-08-22 |  | 32d |  | 5,847.45 |
| 389 | 3.4.1.1 | SALIDAS PARA DESAGUE D=2" Y D=4" | 4d | 2020-07-02 | 2020-07-06 | 118SF | 80d |  | 5,542.95 |
| 390 | 3.4.1.2 | SALIDAS PARA VENTILACION DE 2" | 2d | 2020-08-21 | 2020-08-22 | 159FF | 32d |  | 304.5 |
| 391 | 3.4.2 | **MOVIMIENTO DE TIERRAS** | 5d | 2020-07-01 | 2020-07-06 |  | 80d |  | 1,070.5 |
| 392 | 3.4.2.1 | EXCAVACION DE ZANJAS PARA TUBERIA | 5d | 2020-07-01 | 2020-07-06 | 118SF | 80d |  | 476.48 |
| 393 | 3.4.2.2 | REFINE Y NIVELACION DE FONDO DE ZANJA | 1d | 2020-07-05 | 2020-07-06 | 118SF | 80d |  | 158.5 |
| 394 | 3.4.2.3 | RELLENO Y COMPACTACION DE ZANJAS | 2d | 2020-07-04 | 2020-07-06 | 118SF | 80d |  | 435.52 |
| 395 | 3.4.3 | **RED DE DISTRIBUCION DE DESAGUE** | 3d | 2020-07-03 | 2020-07-06 |  | 76d | 0d | 10,511.74 |
| 396 | 3.4.3.1 | TUBERIA PVC SAL D=2" PARA DESAGUE | 1d | 2020-07-05 | 2020-07-06 | 118SF | 76d |  | 1,686.78 |
| 397 | 3.4.3.2 | TUBERIA PVC SAL D=4" PARA DESAGUE | 3d | 2020-07-03 | 2020-07-06 | 118SF | 76d |  | 4,772.38 |
| 398 | 3.4.3.3 | SUMIDERO DE BRONCE DE 2" | 2d | 2020-07-04 | 2020-07-06 | 118SF | 76d |  | 440.25 |
| 399 | 3.4.3.4 | REGISTRO DE BRONCE DE 4" | 1d | 2020-07-05 | 2020-07-06 | 118SF | 76d |  | 255.12 |
| 400 | 3.4.3.5 | ACCESORIOS PARA RED DISTRIBUCION DE DESAGÜE | 2d | 2020-07-04 | 2020-07-06 | 118SF | 76d |  | 829.36 |
| 401 | 3.4.3.6 | CAJA DE REGISTRO DE DESAGUE 12" X 24" | 2d | 2020-07-04 | 2020-07-06 | 118SF | 76d |  | 2,057.95 |
| 402 | 3.4.3.7 | PRUEBA HIDRAULICA PARA TUBERIA DE DESAGUE | 1d | 2020-07-05 | 2020-07-06 | 118SF | 76d |  | 469.9 |
| 403 | 3.4.4 | **OTROS** | 4d | 2020-07-06 | 2020-07-09 |  | 76d |  | 8,957.68 |
| 404 | 3.4.4.1 | BIODIGESTOR Y CAJA DE LODOS, INC ACCESORIOS | 4d | 2020-07-06 | 2020-07-09 | 395 | 76d |  | 8,957.68 |
| 405 | 3.5 | **EMPLAME A RED EXISTENTE DE AGUA** | 5d | 2020-07-17 | 2020-07-21 |  | 68d |  | 1,090.23 |
| 406 | 3.5.1 | EXCAVACION MANUAL PARA ZANJAS H<1.00 | 4d | 2020-07-17 | 2020-07-20 | 384FF | 69d |  | 302.56 |
| 407 | 3.5.2 | EMPALME A RED EXISTENTE DE AGUA | 1d | 2020-07-21 | 2020-07-21 | 384 | 68d |  | 787.67 |
| 408 | 3.6 | **EMPALME A RED EXISTENTE DE DESAGÜE** | 4d | 2020-08-23 | 2020-08-26 |  | 32d |  | 6,437.05 |
| 409 | 3.6.1 | EXCAVACION MANUAL PARA ZANJAS, H>1.50M | 4d | 2020-08-23 | 2020-08-26 | 387 | 32d |  | 2,707.99 |
| 410 | 3.6.2 | REFINE Y NIVELACION DE FONDO DE ZANJA | 2d | 2020-08-23 | 2020-08-24 | 387 | 34d |  | 117.81 |
| 411 | 3.6.3 | CAMA DE APOYO CON ARENA GRUESA E=0.10 M | 2d | 2020-08-23 | 2020-08-24 | 387 | 34d |  | 478.17 |
| 412 | 3.6.4 | RELLENO MANUAL COMPACTADO CON MATERIAL PROPIO EXCEDENTE DE CORTE | 1d | 2020-08-23 | 2020-08-23 | 387 | 35d |  | 1,936.99 |
| 413 | 3.6.5 | EMPALME PARA DESAGÜE | 1d | 2020-08-23 | 2020-08-23 | 387 | 35d |  | 1,196.09 |

| ID | WBS | Task | Duration | Start | Finish | Predecessors | Total slack | Free slack | Cost |
| --- | --- | --- | --- | --- | --- | --- | --- | --- | --- |
| 414 | 4 | **INSTALACIONES ELECTRICAS** | 11d | 2020-08-01 | 2020-08-11 |  | 47d |  | 92,264.1 |
| 415 | 4.1 | **INSTALACIONES ELECTRICAS EN INTERIORES** | 6d | 2020-08-01 | 2020-08-06 |  | 51d |  | 14,169.94 |
| 416 | 4.1.1 | SALIDA DE CENTRO DE LUZ | 5d | 2020-08-01 | 2020-08-05 | 311 | 51d | 0d | 7,391.18 |
| 417 | 4.1.2 | SALIDA PARA LUZ DE EMERGENCIA | 3d | 2020-08-01 | 2020-08-03 | 311 | 52d | 0d | 1,140.48 |
| 418 | 4.1.3 | SALIDA PARA TOMACORRIENTE DOBLE CON TOMA A TIERRA | 3d | 2020-08-01 | 2020-08-03 | 311 | 52d | 0d | 4,012.88 |
| 419 | 4.1.4 | SALIDA PARA VENTILADOR (TECHO) | 3d | 2020-08-04 | 2020-08-06 | 418, 417 | 52d |  | 1,625.4 |
| 420 | 4.2 | **INSTALACIONES ELECTRICAS EN EXTERIORES** | 1d | 2020-08-03 | 2020-08-03 |  | 55d |  | 3,981.07 |
| 421 | 4.2.1 | LUZ INGRESO PRINCIPAL | 1d | 2020-08-03 | 2020-08-03 | 222 | 55d |  | 247.38 |
| 422 | 4.2.2 | REFLECTORES EN TECHOS METALICOS 400W | 1d | 2020-08-03 | 2020-08-03 | 222 | 55d |  | 2,661.92 |
| 423 | 4.2.3 | SUMINISTRO E INSTALACION DE ELECTROBOMBA 2.0 HP | 1d | 2020-08-03 | 2020-08-03 | 222 | 55d |  | 1,071.77 |
| 424 | 4.3 | **ARTEFACTOS ELECTRICOS** | 7d | 2020-08-01 | 2020-08-07 |  | 51d |  | 27,781.3 |
| 425 | 4.3.1 | FLUORECENTE RECTO 2X36W INCLUYE EQUIPO DE ARRANQUE | 2d | 2020-08-06 | 2020-08-07 | 416 | 51d |  | 6,446.99 |
| 426 | 4.3.2 | FLUORECENTE CIRCULAR 2X36W INCLUYE EQUIPO DE ARRANQUE | 2d | 2020-08-06 | 2020-08-07 | 416 | 51d |  | 6,057.18 |
| 427 | 4.3.3 | LUZ DE EMERGENCIA 32W | 5d | 2020-08-01 | 2020-08-05 | 416FF | 53d |  | 3,484.08 |
| 428 | 4.3.4 | INTERRUPTOR SIMPLE 01 GOLPE | 5d | 2020-08-01 | 2020-08-05 | 311 | 53d |  | 1,039.65 |
| 429 | 4.3.5 | INTERRUPTOR SIMPLE 02 GOLPE | 5d | 2020-08-01 | 2020-08-05 | 311 | 53d |  | 287.14 |
| 430 | 4.3.6 | INTERRUPTOR SIMPLE 03 GOLPE | 5d | 2020-08-01 | 2020-08-05 | 311 | 53d |  | 631.28 |
| 431 | 4.3.7 | INTERRUPTOR CONMUTADOR | 5d | 2020-08-01 | 2020-08-05 | 311 | 53d |  | 881.4 |
| 432 | 4.3.8 | TOMACORRIENTE DOBLE | 5d | 2020-08-01 | 2020-08-05 | 311 | 53d |  | 3,963.44 |
| 433 | 4.3.9 | VENTILADOR PARA TECHO | 5d | 2020-08-01 | 2020-08-05 | 311 | 53d |  | 4,990.14 |
| 434 | 4.4 | **CAJAS DE PASE FªGº** | 2d | 2020-08-01 | 2020-08-02 |  | 56d |  | 119.98 |
| 435 | 4.4.1 | CAJA DE PASE FªGª | 2d | 2020-08-01 | 2020-08-02 | 418SS, 417SS | 56d |  | 119.98 |
| 436 | 4.5 | **ACOMETIDA Y ALIMENTADORES A TABLEROS** | 11d | 2020-08-01 | 2020-08-11 |  | 47d |  | 29,972.31 |
| 437 | 4.5.1 | **MOVIMIENTO DE TIERRAS** | 4d | 2020-08-01 | 2020-08-04 |  | 54d |  | 2,550.25 |
| 438 | 4.5.1.1 | EXCAVACION MANUAL PARA ZANJAS, H>1.50M | 2d | 2020-08-01 | 2020-08-03 | 206SF | 54d | 0d | 1,692.14 |
| 439 | 4.5.1.2 | RELLENO Y COMPACTACION C/ MAT. PROPIO | 2d | 2020-08-03 | 2020-08-04 | 438 | 54d |  | 858.11 |

| ID | WBS | Task | Duration | Start | Finish | Predecessors | Total slack | Free slack | Cost |
| --- | --- | --- | --- | --- | --- | --- | --- | --- | --- |
| 440 | 4.5.2 | **BUZON Y POZOS PUESTA A TIERRA** | 1d | 2020-08-10 | 2020-08-10 |  | 48d |  | 2,221.75 |
| 441 | 4.5.2.1 | PUESTA A TIERRA | 1d | 2020-08-10 | 2020-08-10 | 206 | 48d |  | 457.27 |
| 442 | 4.5.2.2 | BUZON DE CONCRETO P/ CONDUCTOR NHX | 1d | 2020-08-10 | 2020-08-10 | 206 | 48d |  | 1,764.48 |
| 443 | 4.5.3 | **ACOMETIDA** | 2d | 2020-08-10 | 2020-08-11 |  | 47d |  | 1,185.45 |
| 444 | 4.5.3.1 | ALIMENTADOR A TABLERO GENERAL | 2d | 2020-08-10 | 2020-08-11 | 206 | 47d |  | 1,185.45 |
| 445 | 4.5.4 | **ALIMENTADORES A TABLEROS** | 1d | 2020-08-02 | 2020-08-03 |  | 56d |  | 3,822.1 |
| 446 | 4.5.4.1 | CONDUCTOR DE COBRE DE 6 MM2, NHX-90 | 1d | 2020-08-02 | 2020-08-03 | 206SF | 56d |  | 496.53 |
| 447 | 4.5.4.2 | CONDUCTOR DE COBRE DE 10 MM2, NHX-90 | 1d | 2020-08-02 | 2020-08-03 | 206SF | 56d |  | 1,032.93 |
| 448 | 4.5.4.3 | CONDUCTOR DE COBRE DE 16 MM2, NHX-90 | 1d | 2020-08-02 | 2020-08-03 | 206SF | 56d |  | 524.4 |
| 449 | 4.5.4.4 | CONDUCTOR DE COBRE DE 35 MM2, NHX-90 | 1d | 2020-08-02 | 2020-08-03 | 206SF | 56d |  | 1,768.24 |
| 450 | 4.5.5 | **CIRCUITOS DERIVADOS** | 1d | 2020-08-02 | 2020-08-03 |  | 56d |  | 20,192.76 |
| 451 | 4.5.5.1 | CONDUCTOR DE COBRE DE 2.5 MM2, NH 80 | 1d | 2020-08-02 | 2020-08-03 | 206SF | 56d |  | 10,978.25 |
| 452 | 4.5.5.2 | CONDUCTOR DE COBRE DE 4 MM2, NH 80 | 1d | 2020-08-02 | 2020-08-03 | 206SF | 56d |  | 1,876.94 |
| 453 | 4.5.5.3 | CONDUCTOR DE COBRE DE 6 MM2, NH 80 | 1d | 2020-08-02 | 2020-08-03 | 206SF | 56d |  | 470.66 |
| 454 | 4.5.5.4 | CONDUCTOR DE COBRE DE 10 MM2, NH 80 | 1d | 2020-08-02 | 2020-08-03 | 206SF | 56d |  | 2,607.88 |
| 455 | 4.5.5.5 | CONDUCTOR DE COBRE DE 25 MM2, NH 80 | 1d | 2020-08-02 | 2020-08-03 | 206SF | 56d |  | 4,259.03 |
| 456 | 4.6 | **TABLERO GENERAL Y DISTRIBUCION** | 1d | 2020-08-09 | 2020-08-09 |  | 48d | 0d | 4,672.27 |
| 457 | 4.6.1 | TABLERO GENERAL AUTOSOPORTADO | 1d | 2020-08-09 | 2020-08-09 | 206FF | 48d |  | 1,745.22 |
| 458 | 4.6.2 | T.D. 01 TAB. AUT. | 1d | 2020-08-09 | 2020-08-09 | 206FF | 48d |  | 567.17 |
| 459 | 4.6.3 | T.D. 02 TAB. AUT. | 1d | 2020-08-09 | 2020-08-09 | 206FF | 48d |  | 589.97 |
| 460 | 4.6.4 | T.D. 03 TAB. AUT. | 1d | 2020-08-09 | 2020-08-09 | 206FF | 48d |  | 589.97 |
| 461 | 4.6.5 | T.D. 04 TAB. AUT. | 1d | 2020-08-09 | 2020-08-09 | 206FF | 48d |  | 589.97 |
| 462 | 4.6.6 | T.D. 05 TAB. AUT. | 1d | 2020-08-09 | 2020-08-09 | 206FF | 48d |  | 589.97 |
| 463 | 4.7 | **ALUMBRADO EXTERIOR** | 8d | 2020-08-03 | 2020-08-10 |  | 48d |  | 5,116.44 |
| 464 | 4.7.1 | POSTE METALICO INC. BRAZO DOBLE CON LUMINARIA 60 W | 3d | 2020-08-03 | 2020-08-05 | 206SS | 53d |  | 4,400 |
| 465 | 4.7.2 | IZAJE Y CIMENTACION DE POSTES METALICO H=3.00M | 1d | 2020-08-10 | 2020-08-10 | 206 | 48d |  | 716.44 |

| ID | WBS | Task | Duration | Start | Finish | Predecessors | Total slack | Free slack | Cost |
| --- | --- | --- | --- | --- | --- | --- | --- | --- | --- |
| 466 | 4.8 | **PRUEBAS ELECTRICAS Y PUESTA EN MARCHA** | 1d | 2020-08-10 | 2020-08-10 |  | 48d |  | 6,450.79 |
| 467 | 4.8.1 | PRUEBAS ELECTRICAS Y PUESTA EN SERVICIO | 1d | 2020-08-10 | 2020-08-10 | 456 | 48d |  | 950.79 |
| 468 | 4.8.2 | TRANSFORMADOR DE VOLTAJE | 1d | 2020-08-10 | 2020-08-10 | 456 | 48d |  | 5,500 |
| 469 | 5 | **PLAN DE CONTINGENCIA** | 30d | 2020-04-01 | 2020-04-30 |  | 0d |  | 32,992.22 |
| 470 | 5.1 | **ESTRUCTURAS** | 30d | 2020-04-01 | 2020-04-30 |  | 0d |  | 10,326.11 |
| 471 | 5.1.1 | **TRABAJOS PRELIMINARES** | 30d | 2020-04-01 | 2020-04-30 |  | 0d |  | 8,121.03 |
| 472 | 5.1.1.1 | LIMPIEZA MANUAL DE TERRENO | 3d | 2020-04-01 | 2020-04-03 |  | 0d |  | 289.31 |
| 473 | 5.1.1.2 | LIMPIEZA Y DESINFECCION DE PISOS, MUROS Y VANOS | 5d | 2020-04-04 | 2020-04-08 | 472 | 0d |  | 1,877.81 |
| 474 | 5.1.1.3 | TRAZO DE NIVELES Y REPLANTEO | 3d | 2020-04-09 | 2020-04-11 | 473 | 0d |  | 233.91 |
| 475 | 5.1.1.4 | MOVILIZACION Y DESMOVILIZACION DE MOBILIARIO Y EQUIPAMIENTO ESCOLAR | 1d | 2020-04-30 | 2020-04-30 | 480 | 0d |  | 720 |
| 476 | 5.1.1.5 | DESMONTAJE, TRASLADO Y MONTAJE DE MODULOS PREFABRICADOS | 2d | 2020-04-12 | 2020-04-13 | 474 | 0d | 169d | 5,000 |
| 477 | 5.1.2 | **CONCRETO SIMPLE** | 2d | 2020-04-12 | 2020-04-13 |  | 0d |  | 2,205.08 |
| 478 | 5.1.2.1 | FALSO PISO C:H 1:12 | 2d | 2020-04-12 | 2020-04-13 | 474 | 0d |  | 2,205.08 |
| 479 | 5.2 | **ARQUITECTURA** | 16d | 2020-04-14 | 2020-04-29 |  | 0d |  | 20,454.77 |
| 480 | 5.2.1 | **CARPINTERIA** | 16d | 2020-04-14 | 2020-04-29 |  | 0d |  | 20,454.77 |
| 481 | 5.2.1.1 | SUMINISTRO E INSTALACION DE PLANCHA SUPERBOARD E=6MM PARA TABIQUES DE DOBLE CARA | 8d | 2020-04-14 | 2020-04-21 | 478 | 0d |  | 16,768.46 |
| 482 | 5.2.1.2 | PUERTA CONTRAPLACADA 40MM CON TRIPLAY 6MM, INC. COLOCACION CON MARCO DE MADERA 2"X4" | 4d | 2020-04-22 | 2020-04-25 | 481 | 0d |  | 1,255.72 |
| 483 | 5.2.1.3 | VENTANA DE MADERA CON TRIPLAY 6MM, INC. COLOCACION CON MARCO DE MADERA 2"X2" | 4d | 2020-04-26 | 2020-04-29 | 482 | 0d |  | 2,430.59 |
| 484 | 5.3 | **INSTALACIONES SANITARIAS** | 7d | 2020-04-09 | 2020-04-15 |  | 165d |  | 2,211.34 |
| 485 | 5.3.1 | **APARATOS SANITARIOS Y ACCESORIOS** | 7d | 2020-04-09 | 2020-04-15 |  | 165d |  | 2,211.34 |
| 486 | 5.3.1.1 | INODORO LOSA BLANCO | 2d | 2020-04-09 | 2020-04-10 | 473 | 0d |  | 1,647.44 |
| 487 | 5.3.1.2 | LAVATORIO DE LOSA BLANCA | 2d | 2020-04-11 | 2020-04-12 | 486 | 0d |  | 200 |
| 488 | 5.3.1.3 | COLOCACION DE APARATOS SANITARIOS | 3d | 2020-04-13 | 2020-04-15 | 487 | 0d | 167d | 363.9 |
| 489 | 6 | **MOBILIARIO Y EQUIPAMIENTO** | 5d | 2020-09-23 | 2020-09-27 |  | 0d |  | 258,010.36 |
| 490 | 6.1 | MOBILIARIO ESCOLAR | 5d | 2020-09-23 | 2020-09-27 | 285, 1 | 0d |  | 102,922.69 |
| 491 | 6.2 | EQUIPAMIENTO ESCOLAR | 5d | 2020-09-23 | 2020-09-27 | 285, 1 | 0d |  | 151,087.67 |
| 492 | 6.3 | FLETE TERRESTRE - MOBILIARIO Y EQUIPAMIENTO | 5d | 2020-09-23 | 2020-09-27 | 285, 1 | 0d |  | 4,000 |
